# X软件实施项目 Nov10 2005

Schedule from MS Project, 2006-09-04 to 2006-12-18.

## Calendars

- 标准: Mon-Fri 08:00-12:00, 13:00-17:00; Sat-Sun off.

## Resources

| Resource |
| --- |
| 王可 |
| 李江 |
| 黄涓 |
| 何研 |
| 李凌 |
| 张纤 |
| 葛鹊 |
| 范一 |
| 党新 |
| 赵肖 |
| 肖国 |
| 钱波 |
| 孙训 |
| 郭溱 |
| 李轼 |
| （以下略） |

## Schedule

| ID | WBS | Task | Duration | Start | Finish | Predecessors | Total slack | Free slack | Constraint | Resources | Work | Text1 |
| --- | --- | --- | --- | --- | --- | --- | --- | --- | --- | --- | --- | --- |
| 1 | 1 | **项目管理** | 76d | 2006-09-04 | 2006-12-18 |  | 0d |  |  |  | 228h | （略） |
| 2 | 1.1 | **项目管理计划编制** | 1.75d | 2006-09-04 | 2006-09-05 |  | 67.25d | 0d |  |  | 32h |  |
| 3 | 1.1.1 | 范围说明/定义 | 0.25d | 2006-09-04 | 2006-09-04 |  | 67.25d | 0d |  | 王可; 李江; 黄涓; 何研 | 8h |  |
| 4 | 1.1.2 | 时间进度 | 0.5d | 2006-09-04 | 2006-09-04 | 3 | 67.25d | 0d |  | 王可; 李江 | 8h |  |
| 5 | 1.1.3 | 资源计划 | 0.25d | 2006-09-04 | 2006-09-04 | 3 | 67.5d | 0.25d |  | 王可; 李江 | 4h |  |
| 6 | 1.1.4 | 成本估算 | 0.5d | 2006-09-04 | 2006-09-05 | 4, 5 | 67.25d | 0d |  | 王可 | 4h |  |
| 7 | 1.1.5 | 外包规划 | 0.5d | 2006-09-05 | 2006-09-05 | 6 | 67.25d |  |  | 王可 | 4h |  |
| 8 | 1.1.6 | 其他计划 | 0.5d | 2006-09-05 | 2006-09-05 | 6 | 67.25d |  |  | 王可 | 4h |  |
| 9 | 1.2 | 确定客户方组织 | 2d | 2006-09-04 | 2006-09-05 |  | 74d |  |  | 王可 | 16h |  |
| 10 | 1.3 | **启动会议** | 1d | 2006-09-05 | 2006-09-06 | 2 | 67.25d | 0d |  | 王可; 李江; 黄涓; 何研; 李凌; 张纤; 葛鹊; 范一; 党新 | 72h |  |
| 11 | 1.3.1 | 确定会议日程和参加人员 | 0.5d | 2006-09-05 | 2006-09-06 |  | 69.38d | 0d |  |  |  |  |
| 12 | 1.3.2 | 准备演讲PPT等资料 | 1d | 2006-09-05 | 2006-09-06 |  | 68.88d |  |  |  |  |  |
| 13 | 1.3.3 | 召开项目启动会 | 0.5d | 2006-09-05 | 2006-09-06 |  | 69.38d |  |  |  |  |  |
| 14 | 1.3.4 | 整理会议纪要 | 0.5d | 2006-09-05 | 2006-09-06 |  | 69.38d |  |  |  |  |  |
| 15 | 1.4 | 建设项目文档/数据/程序控制体系 | 1d | 2006-09-06 | 2006-09-07 | 11 | 72.75d |  |  | 李江 | 8h |  |
| 16 | 1.5 | **每周例会** | 76d | 2006-09-04 | 2006-12-18 |  | 0d |  |  |  |  |  |
| 17 | 1.5.1 | 每周例会 1 | 1d | 2006-09-04 | 2006-09-04 |  | 76.62d |  | start no earlier than 2006-09-04 |  |  |  |
| 18 | 1.5.2 | 每周例会 2 | 1d | 2006-09-11 | 2006-09-11 |  | 71.62d |  | start no earlier than 2006-09-11 |  |  |  |
| 19 | 1.5.3 | 每周例会 3 | 1d | 2006-09-18 | 2006-09-18 |  | 66.62d |  | start no earlier than 2006-09-18 |  |  |  |
| 20 | 1.5.4 | 每周例会 4 | 1d | 2006-09-25 | 2006-09-25 |  | 61.62d |  | start no earlier than 2006-09-25 |  |  |  |
| 21 | 1.5.5 | 每周例会 5 | 1d | 2006-10-02 | 2006-10-02 |  | 56.62d |  | start no earlier than 2006-10-02 |  |  |  |
| 22 | 1.5.6 | 每周例会 6 | 1d | 2006-10-09 | 2006-10-09 |  | 51.62d |  | start no earlier than 2006-10-09 |  |  |  |
| 23 | 1.5.7 | 每周例会 7 | 1d | 2006-10-16 | 2006-10-16 |  | 46.62d |  | start no earlier than 2006-10-16 |  |  |  |
| 24 | 1.5.8 | 每周例会 8 | 1d | 2006-10-23 | 2006-10-23 |  | 41.62d |  | start no earlier than 2006-10-23 |  |  |  |
| 25 | 1.5.9 | 每周例会 9 | 1d | 2006-10-30 | 2006-10-30 |  | 36.62d |  | start no earlier than 2006-10-30 |  |  |  |
| 26 | 1.5.10 | 每周例会 10 | 1d | 2006-11-06 | 2006-11-06 |  | 31.62d |  | start no earlier than 2006-11-06 |  |  |  |
| 27 | 1.5.11 | 每周例会 11 | 1d | 2006-11-13 | 2006-11-13 |  | 26.62d |  | start no earlier than 2006-11-13 |  |  |  |
| 28 | 1.5.12 | 每周例会 12 | 1d | 2006-11-20 | 2006-11-20 |  | 21.62d |  | start no earlier than 2006-11-20 |  |  |  |
| 29 | 1.5.13 | 每周例会 13 | 1d | 2006-11-27 | 2006-11-27 |  | 16.62d |  | start no earlier than 2006-11-27 |  |  |  |
| 30 | 1.5.14 | 每周例会 14 | 1d | 2006-12-04 | 2006-12-04 |  | 11.62d |  | start no earlier than 2006-12-04 |  |  |  |
| 31 | 1.5.15 | 每周例会 15 | 1d | 2006-12-11 | 2006-12-11 |  | 6.62d |  | start no earlier than 2006-12-11 |  |  |  |
| 32 | 1.5.16 | 每周例会 16 | 1d | 2006-12-18 | 2006-12-18 |  | 0d |  | start no earlier than 2006-12-18 |  |  |  |
| 33 | 1.6 | 项目评审1 | 0.5d | 2006-09-04 | 2006-09-04 |  | 75.5d |  |  | 王可; 李江; 黄涓; 何研; 李凌 | 20h |  |
| 34 | 1.7 | 项目评审2 | 0.5d | 2006-09-04 | 2006-09-04 |  | 75.5d |  |  | 王可; 李江; 黄涓; 何研; 李凌 | 20h |  |
| 35 | 1.8 | 项目评审3 | 0.5d | 2006-09-04 | 2006-09-04 |  | 75.5d |  |  | 王可; 李江; 黄涓; 何研; 李凌 | 20h |  |
| 36 | 1.9 | 项目收尾总结 | 1d | 2006-09-04 | 2006-09-04 |  | 75d |  |  | 王可; 李江; 黄涓; 何研; 李凌 | 40h |  |

| ID | WBS | Task | Duration | Start | Finish | Predecessors | Total slack | Free slack | Resources | Work |
| --- | --- | --- | --- | --- | --- | --- | --- | --- | --- | --- |
| 38 | 2 | **立项** | 2.12d | 2006-09-04 | 2006-09-06 |  | 6.38d | 0d |  | 56h |
| 39 | 2.1 | 评估商业机会 | 0.5d | 2006-09-04 | 2006-09-04 |  | 6.38d | 0d | 李轼 | 4h |
| 40 | 2.2 | **合同评审** | 0.5d | 2006-09-04 | 2006-09-04 | 39 | 6.38d | 0d |  | 24h |
| 41 | 2.2.1 | 软件评审 | 0.5d | 2006-09-04 | 2006-09-04 |  | 6.38d |  | 肖国; 钱波 | 8h |
| 42 | 2.2.2 | 硬件评审 | 0.5d | 2006-09-04 | 2006-09-04 |  | 6.38d |  | 郭溱 | 4h |
| 43 | 2.2.3 | 服务评审 | 0.5d | 2006-09-04 | 2006-09-04 |  | 6.38d |  | 党新 | 4h |
| 44 | 2.2.4 | 分包评审 | 0.5d | 2006-09-04 | 2006-09-04 |  | 6.38d |  | 党新 | 4h |
| 45 | 2.2.5 | 成本/价格评审 | 0.5d | 2006-09-04 | 2006-09-04 |  | 6.38d |  | 钱波 | 4h |
| 46 | 2.3 | 起草立项报告 | 0.5d | 2006-09-05 | 2006-09-05 | 40 | 6.38d | 0d | 王可 | 4h |
| 47 | 2.4 | 立项评审 | 0.12d | 2006-09-05 | 2006-09-05 | 46 | 6.38d | 0d | 李轼; 肖国; 钱波; 王可 | 4h |
| 48 | 2.5 | 立项批准 | 0.5d | 2006-09-05 | 2006-09-06 | 47 | 6.38d |  | 李轼 | 4h |
| 49 | 2.6 | 内部交接 | 1d | 2006-09-04 | 2006-09-04 |  | 7.5d |  | 王可; 李江 | 16h |
| 51 | 3 | **理念及产品培训** | 6d | 2006-09-06 | 2006-09-14 |  | 67.25d |  |  |  |
| 52 | 3.1 | 培训前准备 | 1d | 2006-09-06 | 2006-09-07 | 10 | 67.25d | 0d |  |  |
| 53 | 3.2 | 理念培训 | 1d | 2006-09-07 | 2006-09-08 | 52 | 67.25d | 0d |  |  |
| 54 | 3.3 | 标准产品培训 | 3d | 2006-09-08 | 2006-09-13 | 53 | 67.25d | 0d |  |  |
| 55 | 3.4 | 培训考核并确认 | 1d | 2006-09-13 | 2006-09-14 | 54 | 67.25d |  |  |  |
| 57 | 4 | **需求确定** | 27.5d | 2006-09-06 | 2006-10-13 |  | 6.38d | 0d |  | 552h |
| 58 | 4.1 | 审阅所有相关文档 | 1d | 2006-09-06 | 2006-09-07 | 38 | 6.38d | 0d | 王可; 李江; 黄涓; 何研; 李凌 | 40h |
| 59 | 4.2 | 准备调研提纲、问卷 | 1d | 2006-09-07 | 2006-09-08 | 58 | 6.38d | 0d |  |  |
| 60 | 4.3 | 制定调研计划 | 0.5d | 2006-09-08 | 2006-09-08 | 59 | 6.38d | 0d |  |  |
| 61 | 4.4 | 详细业务需求调研 | 5d | 2006-09-08 | 2006-09-15 | 60 | 6.38d | 0d |  |  |
| 62 | 4.5 | 初步分析 | 1d | 2006-09-15 | 2006-09-18 | 61 | 6.38d | 0d | 王可; 李江; 黄涓 | 24h |
| 63 | 4.6 | 需求和产品匹配分析 | 2d | 2006-09-18 | 2006-09-20 | 62 | 6.38d | 0d |  |  |
| 64 | 4.7 | 编写需求说明的初稿 | 2d | 2006-09-20 | 2006-09-22 | 63 | 6.38d | 0d | 王可; 李江; 黄涓 | 48h |
| 65 | 4.8 | 与客户讨论初稿 | 1d | 2006-09-22 | 2006-09-25 | 64 | 6.38d | 0d | 王可; 李江; 黄涓 | 24h |
| 66 | 4.9 | 详细需求分析 | 5d | 2006-09-25 | 2006-10-02 | 65 | 6.38d | 0d | 王可; 李江; 黄涓; 何研; 李凌 | 200h |
| 67 | 4.10 | 编写/汇编项目需求说明书 | 3d | 2006-10-02 | 2006-10-05 | 66 | 6.38d | 0d | 王可; 李江; 黄涓; 何研; 李凌 | 120h |
| 68 | 4.11 | 内部评审 | 1d | 2006-10-05 | 2006-10-06 | 67 | 6.38d | 0d | 王可; 李江; 黄涓; 何研; 李凌 | 40h |
| 69 | 4.12 | 需求修改 | 2d | 2006-10-06 | 2006-10-10 | 68 | 6.38d | 0d | 黄涓 | 16h |
| 70 | 4.13 | 客户需求评审 | 1d | 2006-10-10 | 2006-10-11 | 69 | 6.38d | 0d | 王可; 李江 | 16h |
| 71 | 4.14 | 需求修改 | 1d | 2006-10-11 | 2006-10-12 | 70 | 6.38d | 0d | 李江; 黄涓 | 16h |
| 72 | 4.15 | 需求确认并取得签字 | 1d | 2006-10-12 | 2006-10-13 | 71 | 6.38d |  | 王可 | 8h |

| ID | WBS | Task | Type | Duration | Start | Finish | Predecessors | Total slack | Free slack | Resources | Work |
| --- | --- | --- | --- | --- | --- | --- | --- | --- | --- | --- | --- |
| 74 | 5 | **项目技术计划编制** |  | 15d | 2006-10-13 | 2006-11-03 |  | 31.38d |  |  | 264h |
| 75 | 5.1 | 项目质量计划编制 |  | 3d | 2006-10-13 | 2006-10-18 | 57 | 31.38d | 0d | 黄涓 | 24h |
| 76 | 5.2 | 项目系统测试计划编制 |  | 3d | 2006-10-18 | 2006-10-23 | 75 | 31.38d | 0d | 李凌; 张纤 | 48h |
| 77 | 5.3 | 项目集成测试计划编制 |  | 3d | 2006-10-23 | 2006-10-26 | 76 | 31.38d | 0d | 李凌; 张纤 | 48h |
| 78 | 5.4 | 项目单元测试计划编制 |  | 3d | 2006-10-26 | 2006-10-31 | 77 | 31.38d | 0d | 李凌; 张纤 | 48h |
| 79 | 5.5 | 项目配置管理计划编制 |  | 3d | 2006-10-31 | 2006-11-03 | 78 | 31.38d |  | 李凌; 张纤 | 48h |
| 80 | 5.6 | 项目支持/维护计划编制 |  | 3d | 2006-10-18 | 2006-10-23 | 75 | 40.38d |  | 葛鹊 | 24h |
| 81 | 5.7 | 项目验收计划编制 |  | 3d | 2006-10-18 | 2006-10-23 | 75 | 40.38d |  | 范一 | 24h |
| 83 | 6 | **系统设计** |  | 38.5d | 2006-09-07 | 2006-10-31 |  | 6.38d | 0d |  | 968h |
| 84 | 6.1 | **概要设计** |  | 27.5d | 2006-09-07 | 2006-10-16 |  | 6.38d | 0d |  | 336h |
| 85 | 6.1.1 | 审阅所有相关文档 |  | 1d | 2006-10-13 | 2006-10-16 | 57 | 6.38d |  | 王可; 李江; 黄涓; 何研; 李凌; 张纤; 葛鹊; 范一 | 64h |
| 86 | 6.1.2 | 编写/阅读概要设计的规范 |  | 0.5d | 2006-09-07 | 2006-09-07 | 58 | 27.38d | 0d | 王可; 李江; 黄涓; 何研; 李凌; 张纤; 葛鹊; 范一 | 32h |
| 87 | 6.1.3 | **概要设计分析/文档编写** |  | 5d | 2006-09-07 | 2006-09-14 |  | 27.38d | 0d |  | 176h |
| 88 | 6.1.3.1 | 任务1 |  | 3d | 2006-09-07 | 2006-09-12 | 86 | 29.38d |  | 王可; 李江 | 48h |
| 89 | 6.1.3.2 | 任务2 |  | 5d | 2006-09-07 | 2006-09-14 | 86 | 27.38d |  | 黄涓; 何研 | 80h |
| 90 | 6.1.3.3 | 任务3 |  | 2d | 2006-09-07 | 2006-09-11 | 86 | 30.38d |  | 李凌; 张纤 | 32h |
| 91 | 6.1.3.4 | 任务4 |  | 1d | 2006-09-07 | 2006-09-08 | 86 | 31.38d |  | 葛鹊; 范一 | 16h |
| 92 | 6.1.4 | 概要设计评审 |  | 1d | 2006-09-14 | 2006-09-15 | 87 | 27.38d |  | 王可; 李江; 黄涓; 何研; 李凌; 张纤; 葛鹊; 范一 | 64h |
| 93 | 6.2 | **详细设计** |  | 10.5d | 2006-10-16 | 2006-10-31 |  | 6.38d | 0d |  | 620h |
| 94 | 6.2.1 | 审阅所有相关文档 |  | 1d | 2006-10-16 | 2006-10-17 | 84 | 6.38d | 0d | 黄涓; 何研; 李凌; 张纤; 葛鹊; 范一; 党新; 赵肖; 肖国; 钱波; 孙训 | 88h |
| 95 | 6.2.2 | 编写/阅读详细设计的规范 |  | 0.5d | 2006-10-17 | 2006-10-18 | 94 | 6.38d | 0d | 黄涓; 何研; 李凌; 张纤; 葛鹊; 范一; 党新; 赵肖; 肖国; 钱波; 孙训 | 44h |
| 96 | 6.2.3 | **详细设计分析/文档编写** |  | 8d | 2006-10-18 | 2006-10-30 |  | 6.38d | 0d |  | 400h |
| 97 | 6.2.3.1 | 任务1 |  | 5d | 2006-10-18 | 2006-10-25 | 95 | 9.38d |  | 孙训; 郭溱; 李轼 | 120h |
| 98 | 6.2.3.2 | 任务2 |  | 8d | 2006-10-18 | 2006-10-30 | 95 | 6.38d |  | 党新; 赵肖; 肖国 | 192h |
| 99 | 6.2.3.3 | 任务3 |  | 4d | 2006-10-18 | 2006-10-24 | 95 | 10.38d |  | 李凌; 张纤 | 64h |
| 100 | 6.2.3.4 | 任务4 |  | 1d | 2006-10-18 | 2006-10-19 | 95 | 13.38d |  | 范一; 黄涓; 何研 | 24h |
| 101 | 6.2.4 | 详细设计评审 |  | 1d | 2006-10-30 | 2006-10-31 | 96 | 6.38d |  | 黄涓; 何研; 李凌; 张纤; 葛鹊; 范一; 党新; 赵肖; 肖国; 钱波; 孙训 | 88h |
| 102 | 6.3 | 设计阶段总结 |  | 0.5d | 2006-10-31 | 2006-10-31 | 93 | 6.38d |  | 王可; 李江; 黄涓 | 12h |
| 103 | 7 | 设计完成 | milestone | 0d | 2006-10-31 | 2006-10-31 | 83 | 6.38d | 0d |  |  |

| ID | WBS | Task | Duration | Start | Finish | Predecessors | Total slack | Free slack | Resources | Work |
| --- | --- | --- | --- | --- | --- | --- | --- | --- | --- | --- |
| 105 | 8 | **编码** | 10d? | 2006-10-31 | 2006-11-14 |  | 6.38d | 0d |  | 648h |
| 106 | 8.1 | 审阅所有相关文档 | 1d | 2006-10-31 | 2006-11-01 | 103 | 6.38d | 0d | 黄涓; 何研; 李凌; 张纤; 葛鹊 | 40h |
| 107 | 8.2 | 编写/阅读编码的规范 | 0.5d | 2006-11-01 | 2006-11-02 | 106 | 14.88d |  | 黄涓; 何研; 李凌; 张纤; 葛鹊 | 20h |
| 108 | 8.3 | 建立编码开发环境 | 2d | 2006-11-01 | 2006-11-03 | 106 | 6.38d | 0d | 何研; 李凌 | 32h |
| 109 | 8.4 | **各任务编码工作** | 1d? | 2006-11-03 | 2006-11-06 |  | 6.38d | 0d |  | 136h |
| 110 | 8.4.1 | **任务1** | 1d? | 2006-11-03 | 2006-11-06 | 108 | 6.38d |  | 何研; 李凌; 张纤; 葛鹊 | 32h |
| 111 | 8.4.1.1 | …… | 1d? | 2006-11-03 | 2006-11-06 |  | 6.38d |  |  |  |
| 112 | 8.4.1.2 | …… | 1d? | 2006-11-03 | 2006-11-06 |  | 6.38d |  |  |  |
| 113 | 8.4.1.3 | …… | 1d? | 2006-11-03 | 2006-11-06 |  | 6.38d |  |  |  |
| 114 | 8.4.2 | **任务2** | 1d? | 2006-11-03 | 2006-11-06 | 108 | 6.38d |  | 范一; 党新; 赵肖; 肖国 | 32h |
| 115 | 8.4.2.1 | …… | 1d? | 2006-11-03 | 2006-11-06 |  | 6.38d |  |  |  |
| 116 | 8.4.2.2 | …… | 1d? | 2006-11-03 | 2006-11-06 |  | 6.38d |  |  |  |
| 117 | 8.4.3 | **任务3** | 1d? | 2006-11-03 | 2006-11-06 | 108 | 6.38d |  | 钱波; 孙训; 郭溱; 李轼 | 32h |
| 118 | 8.4.3.1 | …… | 1d? | 2006-11-03 | 2006-11-06 |  | 6.38d |  |  |  |
| 119 | 8.4.3.2 | …… | 1d? | 2006-11-03 | 2006-11-06 |  | 6.38d |  |  |  |
| 120 | 8.4.4 | **任务4** | 1d? | 2006-11-03 | 2006-11-06 | 108 | 6.38d |  | 郭溱; 李轼; 李凌; 张纤; 葛鹊 | 40h |
| 121 | 8.4.4.1 | …… | 1d? | 2006-11-03 | 2006-11-06 |  | 6.38d |  |  |  |
| 122 | 8.4.4.2 | …… | 1d? | 2006-11-03 | 2006-11-06 |  | 6.38d |  |  |  |
| 123 | 8.5 | 代码审查 | 6d | 2006-11-06 | 2006-11-14 | 109 | 6.38d |  | 黄涓; 何研; 李凌; 张纤; 葛鹊 | 240h |
| 124 | 8.6 | 单元测试用例及其他准备工作 | 2d | 2006-11-06 | 2006-11-08 | 109 | 7.96d | 0d | 黄涓; 何研; 李凌; 张纤; 葛鹊 | 80h |
| 125 | 8.7 | 单元测试 | 2d | 2006-11-08 | 2006-11-10 | 124 | 7.96d | 0d | 黄涓; 何研; 李凌; 张纤; 葛鹊 | 80h |
| 126 | 8.8 | 编码阶段总结 | 0.42d | 2006-11-10 | 2006-11-13 | 125 | 7.96d |  | 黄涓; 何研; 李凌; 张纤; 葛鹊; 王可 | 20h |
| 128 | 9 | **集成测试** | 4d | 2006-11-14 | 2006-11-20 | 105 | 6.38d | 0d | （以下略） | 32h |
| 129 | 9.1 | **准备工作** | 4d | 2006-11-14 | 2006-11-20 |  | 6.38d |  |  |  |
| 130 | 9.1.1 | 审阅所有相关文档 | 1d | 2006-11-14 | 2006-11-15 |  | 9.38d |  |  |  |
| 131 | 9.1.2 | 细化集成测试计划 | 1d | 2006-11-14 | 2006-11-15 |  | 9.38d |  |  |  |
| 132 | 9.1.3 | 准备测试硬件 | 4d | 2006-11-14 | 2006-11-20 |  | 6.38d |  |  |  |
| 133 | 9.1.4 | 准备测试软件环境 | 2d | 2006-11-14 | 2006-11-16 |  | 8.38d |  |  |  |
| 134 | 9.1.5 | 准备测试用例及其他必备材料 | 4d | 2006-11-14 | 2006-11-20 |  | 6.38d |  |  |  |
| 135 | 9.1.6 | 测试用例及其他测试材料的审查 | 2d | 2006-11-14 | 2006-11-16 |  | 8.38d |  |  |  |
| 136 | 9.1.7 | 生成/准备待测系统/任务 | 2d | 2006-11-14 | 2006-11-16 |  | 8.38d |  |  |  |
| 137 | 9.2 | 实施测试工作 | 3d | 2006-11-14 | 2006-11-17 |  | 7.38d |  |  |  |
| 138 | 9.3 | 测试结果查验 | 1d | 2006-11-14 | 2006-11-15 |  | 9.38d |  |  |  |
| 139 | 9.4 | 编写测试报告 | 2d | 2006-11-14 | 2006-11-16 |  | 8.38d |  |  |  |
| 140 | 9.5 | 测试评审 | 1d | 2006-11-14 | 2006-11-15 |  | 9.38d |  |  |  |
| 141 | 9.6 | 问题/缺陷汇编及分析 | 1d | 2006-11-14 | 2006-11-15 |  | 9.38d |  |  |  |
| 142 | 9.7 | 软件修改 | 3d | 2006-11-14 | 2006-11-17 |  | 7.38d |  |  |  |

| ID | WBS | Task | Duration | Start | Finish | Predecessors | Total slack | Free slack |
| --- | --- | --- | --- | --- | --- | --- | --- | --- |
| 144 | 10 | **系统测试** | 4d | 2006-11-20 | 2006-11-24 | 128 | 6.38d | 0d |
| 145 | 10.1 | **准备工作** | 4d | 2006-11-20 | 2006-11-24 |  | 6.38d |  |
| 146 | 10.1.1 | 审阅所有相关文档 | 1d | 2006-11-20 | 2006-11-21 |  | 9.38d |  |
| 147 | 10.1.2 | 细化系统测试计划 | 1d | 2006-11-20 | 2006-11-21 |  | 9.38d |  |
| 148 | 10.1.3 | 准备/确认测试硬件 | 4d | 2006-11-20 | 2006-11-24 |  | 6.38d |  |
| 149 | 10.1.4 | 准备/确认测试软件环境 | 2d | 2006-11-20 | 2006-11-22 |  | 8.38d |  |
| 150 | 10.1.5 | 准备测试用例及其他必备材料 | 4d | 2006-11-20 | 2006-11-24 |  | 6.38d |  |
| 151 | 10.1.6 | 测试用例及其他测试材料的审查 | 2d | 2006-11-20 | 2006-11-22 |  | 8.38d |  |
| 152 | 10.1.7 | 准备待测软件系统 | 2d | 2006-11-20 | 2006-11-22 |  | 8.38d |  |
| 153 | 10.2 | 实施测试工作 | 3d | 2006-11-20 | 2006-11-23 |  | 7.38d |  |
| 154 | 10.3 | 测试结果检验 | 1d | 2006-11-20 | 2006-11-21 |  | 9.38d |  |
| 155 | 10.4 | 编写测试报告 | 2d | 2006-11-20 | 2006-11-22 |  | 8.38d |  |
| 156 | 10.5 | 测试评审 | 1d | 2006-11-20 | 2006-11-21 |  | 9.38d |  |
| 157 | 10.6 | 问题/缺陷汇编及分析 | 1d | 2006-11-20 | 2006-11-21 |  | 9.38d |  |
| 158 | 10.7 | 软件修改 | 3d | 2006-11-20 | 2006-11-23 |  | 7.38d |  |
| 159 | 10.8 | 相关系统/产品文档修改 | 1d | 2006-11-20 | 2006-11-21 |  | 9.38d |  |
| 161 | 11 | **交付/上线准备** | 5d | 2006-11-24 | 2006-12-01 | 144 | 6.38d | 0d |
| 162 | 11.1 | 用户手册编写 | 5d | 2006-11-24 | 2006-12-01 |  | 6.38d |  |
| 163 | 11.2 | 培训筹划 | 1d | 2006-11-24 | 2006-11-27 |  | 10.38d |  |
| 164 | 11.3 | 培训材料编写 | 2d | 2006-11-24 | 2006-11-28 |  | 9.38d |  |
| 165 | 11.4 | 用户手册评审 | 1d | 2006-11-24 | 2006-11-27 |  | 10.38d |  |
| 166 | 11.5 | 培训材料查验 | 1d | 2006-11-24 | 2006-11-27 |  | 10.38d |  |
| 167 | 11.6 | 用户培训 | 3d | 2006-11-24 | 2006-11-29 |  | 8.38d |  |
| 169 | 12 | **交付系统** | 5d | 2006-12-01 | 2006-12-08 | 161 | 6.38d | 0d |
| 170 | 12.1 | 审阅所有相关文档 | 1d | 2006-12-01 | 2006-12-04 |  | 10.38d |  |
| 171 | 12.2 | 交付计划编制 | 2d | 2006-12-01 | 2006-12-05 |  | 9.38d |  |
| 172 | 12.3 | 交付计划评审 | 0.5d | 2006-12-01 | 2006-12-04 |  | 10.88d |  |

| ID | WBS | Task | Type | Duration | Start | Finish | Predecessors | Total slack |
| --- | --- | --- | --- | --- | --- | --- | --- | --- |
| 173 | 12.4 | **准备工作** |  | 5d | 2006-12-01 | 2006-12-08 |  | 6.38d |
| 174 | 12.4.1 | 数据准备/移植 |  | 3d | 2006-12-01 | 2006-12-06 |  | 8.38d |
| 175 | 12.4.2 | 场地环境准备 |  | 2d | 2006-12-01 | 2006-12-05 |  | 9.38d |
| 176 | 12.4.3 | 硬件环境准备 |  | 5d | 2006-12-01 | 2006-12-08 |  | 6.38d |
| 177 | 12.4.4 | 软件环境准备 |  | 4d | 2006-12-01 | 2006-12-07 |  | 7.38d |
| 178 | 12.5 | 软件系统安装 |  | 1d | 2006-12-01 | 2006-12-04 |  | 10.38d |
| 179 | 12.6 | 补丁安装 |  | 1d | 2006-12-01 | 2006-12-04 |  | 10.38d |
| 180 | 12.7 | 就绪检查 |  | 0.5d | 2006-12-01 | 2006-12-04 |  | 10.88d |
| 181 | 12.8 | 切换运行 |  | 1d | 2006-12-01 | 2006-12-04 |  | 10.38d |
| 182 | 12.9 | 切换技术支持 |  | 1d | 2006-12-01 | 2006-12-04 |  | 10.38d |
| 183 | 12.10 | 验收测试 |  | 2d | 2006-12-01 | 2006-12-05 |  | 9.38d |
| 184 | 12.11 | 验收报告编写及签字 |  | 1d | 2006-12-01 | 2006-12-04 |  | 10.38d |
| 186 | 13 | 项目结束 | milestone | 0d | 2006-12-08 | 2006-12-08 | 169 | 6.38d |
